# 03_SwissGroovesPlanung_Parallelisierung-AP_Bontekoe-Rohrer

Schedule from MS Project, 2014-04-01 to 2015-02-09.

## Calendars

- Standard: Mon-Fri 08:00-12:00, 13:00-17:00; Sat-Sun off.

## Resources

| Resource |
| --- |
| Blair Tony |
| Blocher Christoph |
| Berlusconi Silvio |
| Clay Cassius |
| Clinton Hillary |
| Lauda Niki |
| Obama Barak |
| Pelé |
| Putin Vladimir |
| Sarkozy Nicolas |
| Bush George |

## Schedule

| ID | WBS | Task | Type | Duration | Start | Finish | Predecessors | Total slack | Free slack | Constraint | Resources | Work | Profile |
| --- | --- | --- | --- | --- | --- | --- | --- | --- | --- | --- | --- | --- | --- |
| 1 | 1 | Projektstart | milestone, manual | 0d | 2014-04-01 | 2014-04-01 |  |  |  |  |  |  |  |
| 2 | 2 | **SwissGrooves** |  | 225d | 2014-04-01 | 2015-02-09 | 1 | 0d |  |  |  | 5672h |  |
| 3 | 2.1 | **R1 Applikationssoftware** |  | 160d | 2014-06-03 | 2015-01-12 |  | 0d |  |  |  | 2920h |  |
| 4 | 2.1.1 | **R1.1 PoC** |  | 35d | 2014-06-03 | 2014-07-21 | 22 | 0d |  |  |  | 864h |  |
| 5 | 2.1.1.1 | POC-Model |  | 15d | 2014-06-03 | 2014-06-23 |  | 20d |  | start no earlier than 2014-05-28 | Berlusconi Silvio; Blocher Christoph [80%]; Bush George [90%] | 324h | DB-Architekt, SW-Architekt |
| 6 | 2.1.1.2 | POC-System |  | 20d | 2014-06-24 | 2014-07-21 |  | 0d |  | start no earlier than 2014-06-24 | Berlusconi Silvio; Blocher Christoph [80%]; Bush George [90%] | 432h | DB-Architekt, SW-Architekt |
| 7 | 2.1.1.3 | POC-CD |  | 15d | 2014-06-03 | 2014-06-23 |  | 15d |  | start no earlier than 2014-05-13 | Obama Barak [90%] | 108h | Marketing |
| 8 | 2.1.2 | **R1.2 AR1.0** |  | 80d | 2014-09-23 | 2015-01-12 |  | 0d |  |  |  | 2056h |  |
| 9 | 2.1.2.1 | **R1.2.1 Basic** |  | 30d | 2014-09-23 | 2014-11-03 | 26 | 0d |  |  |  | 608h |  |
| 10 | 2.1.2.1.1 | App-Design |  | 30d | 2014-09-23 | 2014-11-03 |  | 0d |  |  | Blocher Christoph [80%] | 192h | SW-Architekt |
| 11 | 2.1.2.1.2 | App-Spez |  | 25d | 2014-09-23 | 2014-10-27 |  | 5d |  |  | Sarkozy Nicolas | 200h | Requirement-Engineer |
| 12 | 2.1.2.1.3 | App-DB |  | 30d | 2014-09-23 | 2014-11-03 |  | 0d |  |  | Bush George [90%] | 216h | DB-Architekt |
| 13 | 2.1.2.2 | **R1.2.2 Release** |  | 50d | 2014-11-04 | 2015-01-12 | 9, 26 | 0d |  |  |  | 1448h |  |
| 14 | 2.1.2.2.1 | App-Content |  | 25d | 2014-11-04 | 2014-12-08 |  | 25d |  |  | Blair Tony | 200h | Technischer Redaktor |
| 15 | 2.1.2.2.2 | App-Identity |  | 20d | 2014-11-04 | 2014-12-01 |  | 30d |  |  | Blocher Christoph [80%] | 128h | SW-Entwickler |
| 16 | 2.1.2.2.3 | App-Social |  | 30d | 2014-11-04 | 2014-12-15 |  | 20d |  |  | Berlusconi Silvio | 240h | SW-Entwickler |
| 17 | 2.1.2.2.4 | App-Cash |  | 45d | 2014-11-04 | 2015-01-12 |  | 0d |  |  | Lauda Niki | 360h | SW-Entwickler |
| 18 | 2.1.2.2.5 | App-Trace |  | 45d | 2014-11-04 | 2015-01-05 |  | 5d |  |  | Clay Cassius | 360h | SW-Entwickler |
| 19 | 2.1.2.2.6 | App-Feedback |  | 20d | 2014-11-04 | 2014-12-01 |  | 30d |  |  | Pelé | 160h | SW-Entwickler |
| 20 | 2.2 | **R2 Applikationskonzept** |  | 200d | 2014-05-06 | 2015-02-09 | 1 | 0d |  |  |  | 1872h |  |
| 21 | 2.2.1 | **R2.1 AK** |  | 100d | 2014-05-06 | 2014-09-22 |  | 0d |  |  |  | 1540.8h |  |
| 22 | 2.2.1.1 | **R2.1.1 AK0.5** |  | 20d | 2014-05-06 | 2014-06-02 | 54, 58 | 15d | 0d |  |  | 446.4h |  |
| 23 | 2.2.1.1.1 | Prototyp-Model |  | 10d | 2014-05-06 | 2014-05-19 |  | 25d |  | start no earlier than 2014-05-05 | Berlusconi Silvio; Blocher Christoph [80%]; Bush George [90%] | 172.8h | DB-Architekt, SW-Architekt |
| 24 | 2.2.1.1.2 | Prototyp-System |  | 12d | 2014-05-16 | 2014-06-02 |  | 15d |  | start no earlier than 2014-05-16 | Blocher Christoph [80%]; Berlusconi Silvio; Bush George [90%] | 216h | System-Engineer, Network-Engineer |
| 25 | 2.2.1.1.3 | Prototyp-CD |  | 8d | 2014-05-06 | 2014-05-15 |  | 27d |  |  | Obama Barak [90%] | 57.6h | Marketing |

Notes:
- 1: SwissGrooves
- 4: Proof of Concept
- 5: Prototyp: Kontext-Diagramm Informatiosnmodell Funktionsgliederung
- 6: System Design: Hardware / Software
- 7: Corporate Design / Benutzeroberfläche
- 8: Applikationsrelease 1.0
- 9: Basis-Release
- 10: Detailliertes Design Detaillierte Beschreibung der Benutzeroberfläche & Navigationsstruktur Usability Styleguide
- 11: Funktionale und nichtfunktionale Spezifikation Schnittstellenkonzept
- 12: Datenmodell
- 13: Release
- 14: Content-Management inkl. Aktualität (Produkt-Fotos etc.)
- 15: Identitiy-Management / Kundenlogin (Kunden-IDs)
- 16: Social-Features
- 17: Rabatt Optionen Zahlungs-Dienstleistung Inkasso-Dienstleistung
- 18: Auslieferung und Tracking Optionen
- 19: Feedback und Beschwerdemanagement
- 21: Applikationskonzept „SwissGrooves
- 22: Applikationskonzept „SwissGrooves für den Pilot/PoC
- 23: Prototyp: Kontext-Diagramm Informatiosnmodell Funktionsgliederung
- 24: System Design: Hardware / Software
- 25: Corporate Design / Benutzeroberfläche

| ID | WBS | Task | Duration | Start | Finish | Predecessors | Total slack | Constraint | Resources | Work | Profile |
| --- | --- | --- | --- | --- | --- | --- | --- | --- | --- | --- | --- |
| 26 | 2.2.1.2 | **R2.1.2 AK-Spez** | 45d | 2014-07-22 | 2014-09-22 |  | 0d |  |  | 1094.4h |  |
| 27 | 2.2.1.2.1 | **R2.1.2.1 Basic** | 20d | 2014-07-22 | 2014-08-18 | 4 | 0d |  |  | 312h |  |
| 28 | 2.2.1.2.1.1 | Concept-Design | 15d | 2014-07-22 | 2014-08-18 |  | 0d |  | Obama Barak [90%] | 108h | Marketing |
| 29 | 2.2.1.2.1.2 | Concept-Spez | 12d | 2014-07-22 | 2014-08-06 |  | 2d |  | Sarkozy Nicolas | 96h | Requirement-Engineer |
| 30 | 2.2.1.2.1.3 | Concept-DB | 15d | 2014-07-22 | 2014-08-11 |  | 5d |  | Bush George [90%] | 108h | DB-Architekt |
| 31 | 2.2.1.2.2 | **R2.1.2.2 Release** | 25d | 2014-08-19 | 2014-09-22 | 4, 27 | 0d |  |  | 782.4h |  |
| 32 | 2.2.1.2.2.1 | Concept-Content | 12d | 2014-08-19 | 2014-09-03 |  | 13d |  | Blair Tony | 96h | Technischer Redaktor |
| 33 | 2.2.1.2.2.2 | Concept-Identity | 12d | 2014-08-19 | 2014-09-03 |  | 13d |  | Obama Barak [90%] | 86.4h | SW-Entwickler |
| 34 | 2.2.1.2.2.3 | Concept-Social | 15d | 2014-09-01 | 2014-09-19 |  | 1d |  | Berlusconi Silvio | 120h | SW-Entwickler |
| 35 | 2.2.1.2.2.4 | Concept-Cash | 25d | 2014-08-19 | 2014-09-22 |  | 0d |  | Lauda Niki | 200h | SW-Entwickler |
| 36 | 2.2.1.2.2.5 | Concept-Trace | 25d | 2014-08-19 | 2014-09-22 |  | 0d |  | Clay Cassius | 200h | SW-Entwickler |
| 37 | 2.2.1.2.2.6 | Concept-Feedback | 10d | 2014-08-19 | 2014-09-08 |  | 10d |  | Pelé | 80h | SW-Entwickler |
| 38 | 2.2.2 | **R2.2 TK** | 135d | 2014-07-22 | 2015-01-26 |  | 10d |  |  | 128h |  |
| 39 | 2.2.2.1 | **R2.2.1 TK-PoC** | 20d | 2014-07-22 | 2014-08-18 | 4 | 125d |  |  | 64h |  |
| 40 | 2.2.2.1.1 | Testkonzept | 10d | 2014-07-22 | 2014-08-18 |  | 125d |  | Clinton Hillary [80%] | 64h | Test-Engineer |
| 41 | 2.2.2.2 | **R2.2.2 TK-Complete** | 10d | 2015-01-13 | 2015-01-26 | 8 | 10d |  |  | 64h |  |
| 42 | 2.2.2.2.1 | TK-Complete | 10d | 2015-01-13 | 2015-01-26 |  | 10d |  | Clinton Hillary [80%] | 64h | Test-Engineer |
| 43 | 2.2.3 | **R2.3 BHB** | 20d | 2015-01-13 | 2015-02-09 | 8 | 0d |  |  | 160h |  |
| 44 | 2.2.3.1 | BHB-Doc | 5d | 2015-01-13 | 2015-01-19 |  | 15d |  | Sarkozy Nicolas | 40h | Technischer Redaktor |
| 45 | 2.2.3.2 | BHB-Wiki | 5d | 2015-01-20 | 2015-01-26 |  | 10d | start no earlier than 2015-01-20 | Berlusconi Silvio | 40h | Technischer Redaktor |
| 46 | 2.2.3.3 | BHB-Online | 10d | 2015-01-27 | 2015-02-09 |  | 0d | start no earlier than 2015-01-27 | Lauda Niki | 80h | Technischer Redaktor |
| 47 | 2.2.4 | **R2.4 OHB1.0** | 3d | 2015-01-13 | 2015-01-15 | 8 | 17d |  |  | 43.2h |  |
| 48 | 2.2.4.1 | OHB-Prozesse | 3d | 2015-01-13 | 2015-01-15 |  | 17d |  | Blocher Christoph [80%] | 19.2h | Technischer Redaktor |
| 49 | 2.2.4.2 | OHB-Recovery | 2d | 2015-01-13 | 2015-01-14 |  | 18d |  | Clay Cassius | 16h | Technischer Redaktor |
| 50 | 2.2.4.3 | OHB-Naming | 1d | 2015-01-13 | 2015-01-13 |  | 19d |  | Pelé | 8h | Technischer Redaktor |

Notes:
- 26: Applikationskonzept für „SwissGrooves Vers. 1.0 (definitive Fassung)
- 27: Basis-Concept
- 28: Detailliertes Design Detaillierte Beschreibung der Benutzeroberfläche & Navigationsstruktur Usability Styleguide
- 29: Funktionale und nichtfunktionale Spezifikation Schnittstellenkonzept
- 30: Datenmodell
- 31: Release
- 32: Content-Management inkl. Aktualität (Produkt-Fotos etc.)
- 33: Identitiy-Management / Kundenlogin (Kunden-IDs)
- 34: Social-Features
- 35: Rabatt Optionen Zahlungs-Dienstleistung Inkasso-Dienstleistung
- 36: Auslieferung und Tracking Optionen
- 37: Feedback und Beschwerdemanagement
- 38: Testkonzept
- 39: Testkonzept Vers. 0.5
- 40: Testfälle definieren
- 41: Testkonzept Vers 1.0 für Webshop Vers. 1.0
- 42: Vollständiges Testkonzept erstellen
- 43: Webshop Benutzer-Handbuch
- 44: Benutzerhandbuch in Dokumentenform
- 45: Wiki mit Hinweisen zur Benutzung des Systems
- 46: Online-Hilfe, vom Webshop aus zu erreichen
- 47: Webshop Betriebs-Handbuch
- 48: Wichtigsten IT Prozesse dokumentieren
- 49: Restart / Recovery Prozeduren dokumentieren
- 50: Naming-Konzept definieren

| ID | WBS | Task | Duration | Start | Finish | Predecessors | Total slack | Free slack | Constraint | Resources | Work | Profile |
| --- | --- | --- | --- | --- | --- | --- | --- | --- | --- | --- | --- | --- |
| 51 | 2.3 | **R3 Business-Ergebnisse** | 27d | 2014-04-08 | 2014-05-14 | 1 | 33d |  |  |  | 328h |  |
| 52 | 2.3.1 | **R3.1 BC** | 5d | 2014-04-08 | 2014-04-14 |  | 33d |  |  |  | 36h |  |
| 53 | 2.3.1.1 | BC | 5d | 2014-04-08 | 2014-04-14 |  | 33d | 0d | start no earlier than 2014-04-08 | Obama Barak [90%] | 36h | Marketing |
| 54 | 2.3.2 | **R3.2 BO** | 12d | 2014-04-15 | 2014-04-30 | 53 | 26d | 0d |  |  | 116h |  |
| 55 | 2.3.2.1 | BO-Webshop | 5d | 2014-04-24 | 2014-04-30 |  | 26d |  | start no earlier than 2014-04-24 | Putin Vladimir | 40h | Prozess-Designer |
| 56 | 2.3.2.2 | BO-Schema | 5d | 2014-04-15 | 2014-04-21 |  | 33d |  |  | Obama Barak [90%] | 36h | Marketing |
| 57 | 2.3.2.3 | BO-Strategie | 5d | 2014-04-15 | 2014-04-21 |  | 33d |  |  | Putin Vladimir | 40h | Prozess-Designer |
| 58 | 2.3.3 | **R3.3 RG** | 15d | 2014-04-15 | 2014-05-05 | 53 | 23d | 0d |  |  | 96h |  |
| 59 | 2.3.3.1 | Recht-Feature | 5d | 2014-04-15 | 2014-04-21 |  | 33d |  | start no earlier than 2014-04-07 | Clinton Hillary [80%] | 32h | Rechtlicher-Berater |
| 60 | 2.3.3.2 | Recht-Usab | 5d | 2014-04-22 | 2014-04-28 |  | 28d |  | start no earlier than 2014-04-22 | Clinton Hillary [80%] | 32h | Rechtlicher-Berater |
| 61 | 2.3.3.3 | Recht-AGB | 5d | 2014-04-29 | 2014-05-05 |  | 23d |  | start no earlier than 2014-04-29 | Clinton Hillary [80%] | 32h | Rechtlicher-Berater |
| 62 | 2.3.4 | **R3.4 NP** | 10d | 2014-05-01 | 2014-05-14 | 54 | 193d |  |  |  | 80h |  |
| 63 | 2.3.4.1 | Produkt-Digital | 5d | 2014-05-01 | 2014-05-07 |  | 198d |  | start no earlier than 2014-04-23 | Sarkozy Nicolas | 40h | Technischer Redaktor |
| 64 | 2.3.4.2 | Produkt-Hardware | 5d | 2014-05-08 | 2014-05-14 |  | 193d |  | start no earlier than 2014-05-08 | Sarkozy Nicolas | 40h | Technischer Redaktor |
| 65 | 2.4 | **R4 Rollout** | 20d | 2015-01-13 | 2015-02-09 | 1 | 0d |  |  |  | 320h |  |
| 66 | 2.4.1 | **R4.1 RO** | 10d | 2015-01-13 | 2015-01-26 | 8 | 5d | 0d |  |  | 80h |  |
| 67 | 2.4.1.1 | Konzept-Rollout | 10d | 2015-01-13 | 2015-01-26 |  | 5d |  |  | Blair Tony | 80h | Roll-Out-Engineer |
| 68 | 2.4.2 | **R4.2 MK** | 20d | 2015-01-13 | 2015-02-09 | 8 | 0d |  |  |  | 144h |  |
| 69 | 2.4.2.1 | Konzept-Marketing | 20d | 2015-01-13 | 2015-02-09 |  | 0d |  |  | Obama Barak [90%] | 144h | Marketing |
| 70 | 2.4.3 | **R4.3 SK** | 5d | 2015-01-27 | 2015-02-02 | 8 | 2d |  |  |  | 40h |  |
| 71 | 2.4.3.1 | Konzept-Schulungs | 5d | 2015-01-27 | 2015-02-02 |  | 2d | 0d | start no earlier than 2015-01-27 | Blair Tony | 40h | Roll-Out-Engineer |
| 72 | 2.4.4 | **R4.4 SCH** | 3d | 2015-02-03 | 2015-02-05 | 71 | 2d |  |  |  | 24h |  |
| 73 | 2.4.4.1 | Schulung | 3d | 2015-02-03 | 2015-02-05 |  | 2d |  | start no earlier than 2015-01-27 | Blair Tony | 24h | Roll-Out-Engineer |
| 74 | 2.4.5 | **R4.5 BP** | 5d | 2015-01-27 | 2015-02-02 | 66 | 5d |  |  |  | 32h |  |
| 75 | 2.4.5.1 | Webshop-Befüllung | 5d | 2015-01-27 | 2015-02-02 |  | 5d |  |  | Blocher Christoph [80%] | 32h | Technischer Redaktor |

Notes:
- 52: Business Case „SwissGrooves
- 53: Business Case (klassisch)
- 54: Geschäftsprozesse & -Modell/Strategie „SwissGrooves
- 55: Geschäftsprozesse für den Betrieb des Webshops
- 56: Graphische Darstellung der Produkt-, Service- Informations- und Geldflüsse sowie deren Akteure
- 57: Strategie basierend auf Geschäftsidee, Marktanalyse, Konkurrenzanalyse, Zielgruppen und Erfolgsfaktoren
- 58: Zahlungssystem & rechtliche Grundlagen
- 59: Evaluierung und Beurteilung der zu verwendenden Zahlungsmechanismen
- 60: Kundenfreundlichkeit (Zahlungsmethoden), Sicherheit der Zahlungsmethoden
- 61: AGB mit Jurist verifizieren / anpassen
- 62: Neue Produkte
- 63: Musikstücke zum Herunterladen
- 64: Produkte der Unterhaltungselektronik
- 66: Konzept Rollout SwissGrooves
- 67: Konzept für das Rollout des Webshops inkl. aller relevanten Schrite
- 68: Marketingkonzept
- 69: Marketingkonzept beschreibt Einführungsmassnahmen und Werbung
- 70: Schulungskonzept SwissGrooves
- 71: Schulungskonzept ausarbeiten für Endkunden und interne Mitarbeiter
- 72: Schulungsdurchführung
- 73: Schulungsdurchfühung in Bern und Basel
- 74: Befüllung Webshop
- 75: Befüllung Webshop

| ID | WBS | Task | Duration | Start | Finish | Predecessors | Total slack | Free slack | Constraint | Resources | Work | Profile |
| --- | --- | --- | --- | --- | --- | --- | --- | --- | --- | --- | --- | --- |
| 76 | 2.5 | **R5 PM-Ergebnisse** | 82d | 2014-04-01 | 2014-07-23 | 1 | 143d |  |  |  | 232h |  |
| 77 | 2.5.1 | **R5.1 PA** | 5d | 2014-04-01 | 2014-04-07 |  | 220d |  |  |  | 40h |  |
| 78 | 2.5.1.1 | Projektantrag | 5d | 2014-04-01 | 2014-04-07 |  | 220d |  | start no earlier than 2014-04-01 | Putin Vladimir | 40h | Projektleiter |
| 79 | 2.5.2 | **R5.2 PP** | 17d | 2014-04-22 | 2014-05-14 |  | 193d |  |  |  | 96h |  |
| 80 | 2.5.2.1 | **R5.2.1 PP0.4** | 2d | 2014-04-22 | 2014-04-23 |  | 198d |  |  |  | 16h |  |
| 81 | 2.5.2.1.1 | PP01 | 2d | 2014-04-22 | 2014-04-23 |  | 198d | 5d | start no earlier than 2014-04-22 | Putin Vladimir | 16h | Projektleiter |
| 82 | 2.5.2.2 | **R5.2.2 PP0.7** | 4d | 2014-05-01 | 2014-05-06 | 81 | 193d |  |  |  | 32h |  |
| 83 | 2.5.2.2.1 | PP07 | 4d | 2014-05-01 | 2014-05-06 |  | 193d | 0d | start no earlier than 2014-05-01 | Putin Vladimir | 32h | Projektleiter |
| 84 | 2.5.2.3 | **R5.2.3 PP1.0** | 6d | 2014-05-07 | 2014-05-14 | 83 | 193d |  |  |  | 48h |  |
| 85 | 2.5.2.3.1 | PP10 | 6d | 2014-05-07 | 2014-05-14 |  | 193d |  |  | Putin Vladimir | 48h | Projektleiter |
| 86 | 2.5.3 | **R5.3 RA** | 1d | 2014-07-22 | 2014-07-22 | 4 | 143d | 0d |  |  | 8h |  |
| 87 | 2.5.3.1 | RA | 1d | 2014-07-22 | 2014-07-22 |  | 143d |  |  | Putin Vladimir | 8h | Risk-Manager |
| 88 | 2.5.4 | **R5.4 KP** | 1d | 2014-07-23 | 2014-07-23 | 86 | 143d |  |  |  | 8h |  |
| 89 | 2.5.4.1 | KP | 1d | 2014-07-23 | 2014-07-23 |  | 143d |  |  | Putin Vladimir | 8h | Marketing |
| 90 | 2.5.5 | **R5.5 ST** | 10d | 2014-05-15 | 2014-05-28 |  | 183d |  |  |  | 80h |  |
| 91 | 2.5.5.1 | ST | 10d | 2014-05-15 | 2014-05-28 |  | 183d |  | start no earlier than 2014-05-15 | Putin Vladimir | 80h | Risk-Manager |

Notes:
- 77: Projektantrag
- 78: Projektantrag mit Ausgangszielen, Zielen, Scope und grober Projektplanung
- 79: Projektplan
- 80: Projektplan Version 0.4
- 81: Projektplan gemäss Ergebnisliste
- 82: Projektplan Version 0.7
- 83: Projektplan gemäss Ergebnisliste
- 84: Projektplan Version 1.0
- 85: Projektplan gemäss Ergebnisliste
- 86: Risikoanalyse
- 87: Risikoanalyse gemäss Ergebnisliste
- 88: Kommunikationsplan
- 89: Kommunikationsplan gemäss Ergebnisliste
- 90: Entscheidungsvorlage
- 91: Entscheidungsvorlage: Webshop mieten, Standardlösung kaufen oder OpenSource-Lösung anpassen?
